# Decision making tool SPIDER PLUS 150527

Schedule from MS Project, 2015-06-01 to 2050-01-01, status date 2015-06-01, 23.57 hours a day.
Roadmap SPIDER PLUS
HaCon Ingenieurgesellschaft mbH

## Calendars

- 24 Stunden: Mon-Sun 00:00-24:00.

## Schedule

| ID | WBS | Task | Type | Duration | Start | Finish | Predecessors | Total slack | Free slack | Constraint | Action Field |
| --- | --- | --- | --- | --- | --- | --- | --- | --- | --- | --- | --- |
| 1 | 1 | Phase 1: 2015 - 2020 |  | 55mo | 2015-06-02 | 2020-01-01 |  | 0d |  | as late as possible |  |
| 2 | 2 | Phase 2: 2020 - 2030 |  | 120mo | 2020-01-01 | 2030-01-01 | 1 | 0d |  |  |  |
| 3 | 3 | The Intermediate "Must have 2030" step | milestone | 0mo | 2030-01-01 | 2030-01-01 | 2 | 7440d |  |  |  |
| 4 | 4 | Phase 3: 2030 - 2050 |  | 240mo | 2030-01-01 | 2050-01-01 | 2 | 0d |  |  |  |
| 5 | 5 | Mobility vision 2050 | milestone | 0mo | 2050-01-01 | 2050-01-01 | 4 | 0d |  |  |  |
| 6 | 6 | **Hybrid locomotives** |  | 5580.73d | 2016-01-01 | 2031-01-01 |  | 7067.64d |  |  | Rolling stock |
| 7 | 6.1 | **Freight version – Last mile diesel engine** |  | 5580.73d | 2016-01-01 | 2031-01-01 |  | 7067.64d |  |  | Rolling stock |
| 8 | 6.1.1 | Evaluation of experiences with first generation in service |  | 18mo | 2016-01-01 | 2017-07-01 |  | 8928.37d | 0.73d | start no earlier than 2016-01-01 | Rolling stock |
| 9 | 6.1.2 | Optimisation of technology (2. generation) |  | 24mo | 2017-01-01 | 2019-01-01 | 8SS+12mo | 8927.64d | 0d | start no earlier than 2017-01-01 | Rolling stock |
| 10 | 6.1.3 | European-wide approval procedure |  | 12mo | 2019-01-01 | 2020-01-01 | 9, 268SS+6mo | 8927.64d | 0d |  | Rolling stock |
| 11 | 6.1.4 | Building and test of prototypes (2. generation) in freight services |  | 12mo | 2020-01-01 | 2021-01-01 | 10 | 8927.64d | 0d |  | Rolling stock |
| 12 | 6.1.5 | Industrial production and stepwise integration in pan-European freight services |  | 120mo | 2021-01-01 | 2031-01-01 | 11 | 8927.64d | 0d |  | Rolling stock |
| 13 | 6.1.6 | Milestone (MS) | milestone | 0mo | 2031-01-01 | 2031-01-01 | 12 | 7067.64d |  |  | Rolling stock |
| 14 | 6.2 | **Hybrid powered passenger train sets (E-powered by catenary + battery pack)** |  | 5580d | 2016-01-01 | 2031-01-01 |  | 7068.37d |  |  | Rolling stock |
| 15 | 6.2.1 | Technology development of a first generation based on first prototypes |  | 30mo | 2016-01-01 | 2018-07-02 |  | 8928.37d | 0d | start no earlier than 2016-01-01 | Rolling stock |
| 16 | 6.2.2 | Building and testing of a prototype series |  | 24mo | 2018-07-02 | 2020-07-01 | 15 | 8928.37d | 0d | start no earlier than 2016-01-01 | Rolling stock |
| 17 | 6.2.3 | European-wide approval procedure |  | 12mo | 2020-01-01 | 2020-12-31 | 16SS+18mo, 268SS+6mo | 8928.37d | 0d |  | Rolling stock |
| 18 | 6.2.4 | Industrial production of first generation and stepwise integration in passenger services |  | 60mo | 2020-12-31 | 2025-12-31 | 17 | 8928.37d | 0d |  | Rolling stock |
| 19 | 6.2.5 | Optimisation of technology and development of 2nd generation |  | 18mo | 2024-07-01 | 2025-12-31 | 18SS+42mo | 8928.37d | 0d |  | Rolling stock |
| 20 | 6.2.6 | Industrial production of 2nd generation and stepwise integration in passenger services |  | 60mo | 2025-12-31 | 2031-01-01 | 19 | 8928.37d | 0d |  | Rolling stock |
| 21 | 6.2.7 | MS | milestone | 0mo | 2031-01-01 | 2031-01-01 | 20 | 8928.37d |  |  | Rolling stock |
| 22 | 7 | **Wagons, new materials and technologies** |  | 5580d | 2016-01-01 | 2031-01-01 |  | 7068.37d |  |  | Rolling stock |
| 23 | 7.1 | **New designed freight wagons** |  | 5580d | 2016-01-01 | 2031-01-01 |  | 7068.37d |  |  | Rolling stock |
| 24 | 7.1.1 | Evaluation of future requirements for freight wagons |  | 24mo | 2016-01-01 | 2017-12-31 |  | 7068.37d | 0d | start no earlier than 2016-01-01 | Rolling stock |
| 25 | 7.1.2 | Development of technology for standardised basic elements and Prototypes |  | 18mo | 2017-07-01 | 2018-12-31 | 24SS+18mo | 7068.37d | 0d |  | Rolling stock |
| 26 | 7.1.3 | Building, testing and optimisation of first prototypes in pilot services |  | 12mo | 2018-12-31 | 2020-01-01 | 25 | 8928.37d | 0d |  | Rolling stock |
| 27 | 7.1.4 | European-wide approval of finally designed future freight wagons |  | 12mo | 2020-01-01 | 2020-12-31 | 26, 268SS+6mo | 8928.37d | 0d |  | Rolling stock |
| 28 | 7.1.5 | Industrial production and stepwise integration in freight services |  | 120mo | 2020-12-31 | 2031-01-01 | 27 | 8928.37d | 0d |  | Rolling stock |
| 29 | 7.1.6 | MS | milestone | 0mo | 2031-01-01 | 2031-01-01 | 28 | 8928.37d |  |  | Rolling stock |

Notes:
- 6: ·Hybrid locomotives for last mile services for freight and for interchanges between electrified and non electrified lines for passenger services/ ·First generation in service (freight) and first prototypes in passenger services / ·Development of a second generation for freight (based on improved technologies and experiences with the first generation) until 2030 / ·Development of ready for serial production models for passenger services until 2030
- 23: New designed freight wagon ( Wagons - new materials, modular concepts and technologies) / Procurement of new designed freight waggons (low noise and light weight)
- 24: Evaluation of future requirements for freight wagons (e.g. noise emissions, logistic/transport profiles) and specification
- 25: Development of technology for standardised basic elements and configuration/design of prototypes according to market
- 27: European-wide approval of finally designed future freight wagons (intermodal and wagon load services)

| ID | WBS | Task | Type | Duration | Start | Finish | Predecessors | Total slack | Free slack | Constraint | Action Field |
| --- | --- | --- | --- | --- | --- | --- | --- | --- | --- | --- | --- |
| 30 | 8 | **Braking, automatic coupling, electric wire** |  | 8929.73d? | 2016-01-01 | 2040-01-03 |  | 0.37d |  |  | Rolling stock |
| 31 | 8.1 | **Automatic centre buffer coupler (ACBC)** |  | 8928d | 2016-01-01 | 2040-01-01 |  | 0.37d |  |  | Rolling stock |
| 32 | 8.1.1 | Evaluation of existing technology |  | 18mo | 2016-01-01 | 2017-07-01 |  | 1860.37d | 0d | start no earlier than 2016-01-01 | Rolling stock |
| 33 | 8.1.2 | Investigation of usability |  | 18mo | 2016-12-31 | 2018-07-02 | 32SS+12mo | 1860.37d | 0d |  | Rolling stock |
| 34 | 8.1.3 | Specification of requirements |  | 12mo | 2018-07-02 | 2019-07-02 | 33 | 1860.37d | 0d |  | Rolling stock |
| 35 | 8.1.4 | Development of prototypes |  | 18mo | 2019-07-02 | 2020-12-31 | 34 | 1860.37d | 0d |  | Rolling stock |
| 36 | 8.1.5 | Investigation and evaluation of a pan-European solution |  | 24mo | 2020-07-01 | 2022-07-02 | 35SS+12mo | 1860.37d | 0d |  | Rolling stock |
| 37 | 8.1.6 | European-wide approval |  | 30mo | 2022-07-02 | 2024-12-31 | 36, 268SS+6mo | 1860.37d | 0d |  | Rolling stock |
| 38 | 8.1.7 | Industrial production and stepwise implementation |  | 180mo | 2024-12-31 | 2040-01-01 | 37 | 1860.37d | 0d |  | Rolling stock |
| 39 | 8.1.8 | MS | milestone | 0mo | 2040-01-01 | 2040-01-01 | 38 | 5580.37d |  |  | Rolling stock |
| 40 | 8.2 | **Continuous electric wire (in combination with ACBC)** |  | 8556d | 2017-01-01 | 2040-01-02 |  | 3347.64d |  |  | Rolling stock |
| 41 | 8.2.1 | Investigation of usability and technical-economical evaluation of possible functionalities |  | 18mo | 2017-01-01 | 2018-07-02 |  | 5207.64d | 0d | start no earlier than 2017-01-01 | Rolling stock |
| 42 | 8.2.2 | Specification of requirements and design of respective prototype solutions |  | 12mo | 2018-07-02 | 2019-07-03 | 41 | 5207.64d | 0d |  | Rolling stock |
| 43 | 8.2.3 | Development, building and testing of respective solutions |  | 18mo | 2019-07-03 | 2021-01-01 | 42, 34SS | 5207.64d | 0d |  | Rolling stock |
| 44 | 8.2.4 | Investigation and evaluation of results and agreement of pan-European solutions |  | 24mo | 2020-07-02 | 2022-07-03 | 43SS+12mo, 36SS | 5207.64d | 0d |  | Rolling stock |
| 45 | 8.2.5 | European-wide approval and elaboration of a migration and implementation plan |  | 30mo | 2022-07-03 | 2025-01-01 | 44, 37SS, 268SS+6mo | 5393.64d | 0d |  | Rolling stock |
| 46 | 8.2.6 | Industrial production and stepwise integration |  | 180mo | 2025-01-01 | 2040-01-02 | 45 | 5579.64d | 0d |  | Rolling stock |
| 47 | 8.2.7 | MS | milestone | 0mo | 2040-01-02 | 2040-01-02 | 46 | 5579.64d |  |  | Rolling stock |
| 48 | 8.3 | Electronic braking for freight trains (MS) | milestone | 0.03mo? | 2040-01-02 | 2040-01-03 | 47 | 3718.64d |  |  | Rolling stock |
| 49 | 9 | **Rolling stock design and materials** |  | 8928d | 2016-01-01 | 2040-01-01 |  | 3720.37d |  |  | Technology |
| 50 | 9.1 | **Double stack wagons** |  | 5394d | 2016-01-01 | 2030-07-02 |  | 7254.37d |  |  | Technology |
| 51 | 9.1.1 | Increased Procurement |  | 174mo | 2016-01-01 | 2030-07-02 |  | 7254.37d | 0d | start no earlier than 2016-01-01 | Technology |
| 52 | 9.1.2 | MS - Increased Procurrment | milestone | 0mo | 2030-07-02 | 2030-07-02 | 51 | 7254.37d |  | finish no earlier than 2030-01-01 | Technology |
| 53 | 9.2 | **New designed train sets for future passenger services** |  | 8928d | 2016-01-01 | 2040-01-01 |  | 3720.37d |  |  | Technology |
| 54 | 9.2.1 | Investigation and evaluation of requirements for advanced rail passenger services |  | 18mo | 2016-01-01 | 2017-07-01 |  | 3720.37d | 0d | start no earlier than 2016-01-01 | Technology |
| 55 | 9.2.2 | Deduction of service profiles and specification of train set design for rail passenger services between metropolis |  | 18mo | 2017-07-01 | 2018-12-31 | 54 | 3720.37d | 0d |  | Technology |
| 56 | 9.2.3 | Deduction of service profiles and specification of train set design for intra-regional and inter-regional rail passenger services |  | 18mo | 2017-07-01 | 2018-12-31 | 55SS | 3720.37d | 0d |  | Technology |
| 57 | 9.2.4 | Development of respective train sets |  | 36mo | 2018-12-31 | 2021-12-31 | 56, 55 | 3720.37d | 0d |  | Technology |
| 58 | 9.2.5 | Building and testing of prototypes as well as European-wide approval for serial production |  | 36mo | 2021-12-31 | 2024-12-31 | 57, 268SS+6mo | 3720.37d | 0d |  | Technology |
| 59 | 9.2.6 | Industrial production and stepwise introduction in passenger services |  | 180mo | 2024-12-31 | 2040-01-01 | 58 | 3720.37d | 0d |  | Technology |
| 60 | 9.2.7 | MS | milestone | 0mo | 2040-01-01 | 2040-01-01 | 59 | 3720.37d |  |  | Technology |

Notes:
- 31: ·Development and implementation of an improved automatic centre buffer coupler (ACBC) technology. / ·Development of the technology and elaboration of an implementation/migration plan until 2025. / ·Implementation (stepwise in closed production systems and/or geographical areas/corridors) between 2025-2040.
- 32: Evaluation of existing technology, deduction of optimisation based on requirements of future rail freight services and production profiles
- 33: Investigation of usability and technical-economical evaluation of possible functionalities in intermodal and wagon load services
- 34: Specification of requirements and design of possible prototype solutions
- 35: Development, building and testing of respective prototypes in intermodal and wagon load services
- 36: Investigation and evaluation of results and agreement on a pan-European solution for ACBC in intermodal and wagon load services
- 37: European-wide approval and elaboration of a migration and implementation plan for intermodal and wagon load services
- 38: Industrial production and stepwise integration in rail freight services according to migration and implementation plan
- 40: Continuous electric wire (based on decision of introduction of ACBC -3.1)/ Continuous electric wire in parallel to the ACBC implementation-e.g. as basic requirement for automation of various processes (brake monitoring, automated pin setting and wagon masters activity).
- 41: Investigation of usability and technical-economical evaluation of possible functionalities in intermodal and wagon load services
- 42: Specification of requirements and design of respective prototype solutions for intermodal services and wagon load services according to logistic service profiles
- 43: Development, building and testing of respective solutions for intermodal and wagon load services in combination with ACBC
- 44: Investigation and evaluation of results and agreement of pan-European solutions in combination with ACBC
- 46: Industrial production and stepwise integration in rail freight services according to migration and implementation plan
- 48: Only in combination with continuous electric wire!
- 50: Remarkable extension of double floor passenger trains until 2030 (Commuter/Regional to long distance/HSR services) according to development of demand.
- 54: Investigation and evaluation of mid- to long-term requirements for advanced rail passenger services in Europe
- 55: Deduction of service profiles and specification of train set design for rail passenger services between metropolis
- 56: Deduction of service profiles and specification of train set design for intra-regional and inter-regional rail passenger services
- 57: Development of respective train sets based on specified design, experiences with existing technologies and evaluation of possibilities based on new materials/technologies as well as a technical-economical evaluation including advantages/disadvantages of double stack
- 58: Building and testing of prototypes as well as European-wide approval for serial production of a complete new generation of train sets for passenger services (including results/findings for hybrid train sets - 1.2)
- 59: Industrial production and stepwise introduction in passenger services

| ID | WBS | Task | Type | Duration | Start | Finish | Predecessors | Total slack | Free slack | Constraint | Action Field |
| --- | --- | --- | --- | --- | --- | --- | --- | --- | --- | --- | --- |
| 61 | 10 | **Automation in Movements/Transfers** |  | 12648d | 2016-01-01 | 2050-01-01 |  | 0.37d |  |  | Technology |
| 62 | 10.1 | **Automation of handling of CT units** |  | 9300.73d | 2016-01-01 | 2041-01-01 |  | 3347.64d |  |  | Technology |
| 63 | 10.1.1 | **Crane and storage area** |  | 8928d | 2016-01-01 | 2040-01-01 |  | 3720.37d |  |  | Technology |
| 64 | 10.1.1.1 | Investigation of usability and technical-economical evaluation |  | 18mo | 2016-01-01 | 2017-07-01 |  | 3720.37d | 0d | start no earlier than 2016-01-01 | Technology |
| 65 | 10.1.1.2 | Specification of requirements for automated transfer, movement and storage of CT-units |  | 12mo | 2017-07-01 | 2018-07-02 | 64 | 3720.37d | 0d | start no earlier than 2016-01-01 | Technology |
| 66 | 10.1.1.3 | Specification and design of cranes, mobile devices (e.g. AGV) and storage equipment |  | 18mo | 2018-07-02 | 2020-01-01 | 65 | 3720.37d | 0d | start no earlier than 2016-01-01 | Technology |
| 67 | 10.1.1.4 | Development, testing and final technical-economical evaluation as well as approval |  | 36mo | 2020-01-01 | 2022-12-31 | 66, 268SS+6mo | 3720.37d | 0d | start no earlier than 2016-01-01 | Technology |
| 68 | 10.1.1.5 | Evaluation of results and deduction of recommended specifications |  | 12mo | 2022-12-31 | 2024-01-01 | 67 | 3720.37d | 0d | start no earlier than 2016-01-01 | Technology |
| 69 | 10.1.1.6 | Development of implementation concepts |  | 12mo | 2024-01-01 | 2024-12-31 | 68 | 3720.37d | 0d | start no earlier than 2016-01-01 | Technology |
| 70 | 10.1.1.7 | Stepwise implementation of automation in the European rail based intermodal industry |  | 180mo | 2024-12-31 | 2040-01-01 | 69 | 3720.37d | 0d | start no earlier than 2016-01-01 | Technology |
| 71 | 10.1.1.8 | MS | milestone | 0mo | 2040-01-01 | 2040-01-01 | 70 | 3720.37d | 372.73d |  | Technology |
| 72 | 10.1.2 | **CT-units on wagons** |  | 9300.73d | 2016-01-01 | 2041-01-01 |  | 3347.64d |  |  | Technology |
| 73 | 10.1.2.1 | Investigation of usability and technical-economical evaluation |  | 12mo | 2016-01-01 | 2016-12-31 |  | 4278.37d | 558.73d | start no earlier than 2016-01-01 | Technology |
| 74 | 10.1.2.2 | Specification of requirements and design of respective prototypes |  | 12mo | 2018-07-02 | 2019-07-03 | 73, 41 | 3719.64d | 0d | start no earlier than 2018-01-01 | Technology |
| 75 | 10.1.2.3 | Development, building and testing of respective solutions |  | 18mo | 2019-07-03 | 2021-01-01 | 74 | 3719.64d | 372d | start no earlier than 2016-01-01 | Technology |
| 76 | 10.1.2.4 | Investigation and evaluation of results and agreement of pan-European solutions |  | 24mo | 2021-07-02 | 2023-07-03 | 75SS+12mo, 44SS+12mo | 3347.64d | 0d | start no earlier than 2016-01-01 | Technology |
| 77 | 10.1.2.5 | European-wide approval and elaboration of a migration and implementation plan |  | 30mo | 2023-07-03 | 2026-01-01 | 76, 45SS+6mo | 3347.64d | 0d | start no earlier than 2016-01-01 | Technology |
| 78 | 10.1.2.6 | Industrial production and stepwise integration in rail freight services according to migration and implementation plan |  | 180mo | 2026-01-01 | 2041-01-01 | 77, 46SS | 3347.64d | 0d | start no earlier than 2016-01-01 | Technology |
| 79 | 10.1.2.7 | MS | milestone | 0mo | 2041-01-01 | 2041-01-01 | 78 | 3347.64d | 0d |  | Technology |
| 80 | 10.2 | **Automated (driverless) operations** |  | 12648d | 2016-01-01 | 2050-01-01 |  | 0.37d |  |  | Technology |
| 81 | 10.2.1 | Evaluation of experiences with existing technologies and services |  | 24mo | 2016-01-01 | 2017-12-31 |  | 0.37d | 0d | start no earlier than 2016-01-01 | Technology |
| 82 | 10.2.2 | Elaboration and evaluation of the usability/possibilities and framework conditions |  | 36mo | 2017-12-31 | 2020-12-31 | 81 | 0.37d | 0d | start no earlier than 2016-11-01 | Technology |
| 83 | 10.2.3 | Final evaluation of the findings/results, definition of application areas |  | 36mo | 2020-12-31 | 2024-01-01 | 82 | 0.37d | 0d | start no earlier than 2016-11-01 | Technology |
| 84 | 10.2.4 | Development of technologies and technical-economical evaluation |  | 48mo | 2024-01-01 | 2028-01-01 | 83 | 0.37d | 0d | start no earlier than 2016-11-01 | Technology |
| 85 | 10.2.5 | Definition of pilot projects, building of prototypes (vehicles), improving/adaption of infrastructure, test operations |  | 60mo | 2028-01-01 | 2032-12-31 | 84 | 0.37d | 0d | start no earlier than 2016-11-01 | Technology |
| 86 | 10.2.6 | Evaluation of test results, approval of technologies |  | 48mo | 2032-12-31 | 2036-12-31 | 85 | 0.37d | 0d | start no earlier than 2016-11-01 | Technology |
| 87 | 10.2.7 | International-coordinated implementation plan |  | 36mo | 2036-12-31 | 2040-01-01 | 86 | 0.37d | 0d | start no earlier than 2016-11-01 | Technology |
| 88 | 10.2.8 | Industrial production of components/vehicles and stepwise implementation |  | 120mo | 2040-01-01 | 2050-01-01 | 87 | 0.37d | 0d | start no earlier than 2016-11-01 | Technology |
| 89 | 10.2.9 | MS | milestone | 0mo | 2050-01-01 | 2050-01-01 | 88 | 0.37d |  | start no earlier than 2016-11-01 | Technology |

Notes:
- 62: ·Development and implementation of concepts/components for terminal automation. / ·Demonstration in pilot projects and elaboration of a European wide concept for terminals/nodes and hubs automation in intermodal services along the CNC until 2020. / ·Stepwise implementation in main terminals/nodes and hubs according in the timeframe 2020-2040.
- 64: Investigation of usability and technical-economical evaluation of possible application range in terminals, dry-ports and hubs including the experiences of existing automation technologies and operational procedures in container handling in sea-ports
- 65: Specification of requirements for automated transfer, movement and storage of CT-units based on operational processes
- 66: Specification and design of cranes, mobile devices (e.g. AGV) and storage equipment for future automated handling
- 67: Development, testing and final technical-economical evaluation as well as approval of prototypes in selected terminals
- 68: Evaluation of results and deduction of recommended specifications for automated handling of CT-units in European intermodal rail services in combination with the results/findings of automation of handling/controlling of CT-units on wagons
- 69: Development of suitable national but international coordinated implementation of concepts for the automation of handling of CT-units in main terminals, dry-ports and hubs
- 70: Stepwise implementation of automation in the European rail based intermodal industry
- 73: Investigation of usability and technical-economical evaluation of possible applications according to the pin-setting and controlling procedures according to the loading process in intermodal terminals and hubs in combination with the evaluation of the introduction of electric wire in intermodal wagon fleet
- 74: Specification of requirements and design of respective prototype solutions in combination with results/findings of the introduction of electric wire
- 75: Development, building and testing of respective solutions for intermodal and wagon load services in combination with ACBC and electric wire
- 76: Investigation and evaluation of results and agreement of pan-European solutions in combination with ACBC and electric wire
- 77: European-wide approval and elaboration of a migration and implementation plan in combination with ACBC and electric wire
- 78: Industrial production and stepwise integration in rail freight services according to migration and implementation plan
- 81: Evaluation of state of the art experiences with existing technologies and services of automated driverless operations in the European and global railway area.
- 82: Elaboration and evaluation of the mid-term to long-term usability/possibilities and framework conditions of a future implementation of automated driverless operations in the various fields of rail services in Europe e.g. from single metro lines to rail networks
- 83: Final evaluation of the findings/results, definition of suitable/realistic mid- to long-term application areas in Europe
- 84: Development of respective technologies (infrastructure and vehicle) and technical-economical evaluation of application areas and solutions
- 85: Definition of pilot projects, building of prototypes (vehicles), improving/adaption of infrastructure, test operations
- 86: Evaluation of test results, approval of suitable solutions/technologies, final definition of suitable future application areas
- 87: Development of an international-coordinated implementation plan if suitable for European CNC in combination/coordination with the migration/implementation plan of further ETCS-Levels
- 88: Industrial production of components/vehicles and stepwise implementation (if suitable based on the previous findings/results)

| ID | WBS | Task | Type | Duration | Start | Finish | Predecessors | Total slack | Free slack | Constraint | Action Field |
| --- | --- | --- | --- | --- | --- | --- | --- | --- | --- | --- | --- |
| 90 | 10.3 | **Automated driverless vehicles** |  | 11904d | 2017-12-31 | 2050-01-01 |  | 0.37d |  |  | Technology |
| 91 | 10.3.1 | Increased Procurement |  | 384mo | 2017-12-31 | 2050-01-01 | 81SS+24mo | 0.37d | 0d | start no earlier than 2016-01-01 | Technology |
| 92 | 10.3.2 | MS | milestone | 0mo | 2050-01-01 | 2050-01-01 | 91 | 0.37d |  | start no earlier than 2029-06-01 | Technology |
| 93 | 10.4 | **Automated marshalling yards** |  | 11903.6d | 2018-01-01 | 2050-01-01 |  | 0.37d |  |  | Technology |
| 94 | 10.4.1 | Evaluation of existing technologies and concepts |  | 24mo | 2018-01-01 | 2020-01-01 |  | 5579.93d | 0d | start no earlier than 2018-01-01 | Technology |
| 95 | 10.4.2 | Investigation of usability and technical-economical evaluation |  | 30mo | 2020-01-01 | 2022-07-02 | 94 | 5579.93d | 0d | start no earlier than 2017-01-01 | Technology |
| 96 | 10.4.3 | Specification of requirements, development of components/technologies and concepts for migration/implementation |  | 30mo | 2022-07-02 | 2024-12-31 | 95 | 5579.93d | 5579.56d | start no earlier than 2017-01-01 | Technology |
| 97 | 10.4.4 | Stepwise implementation of technology and migration |  | 120mo | 2040-01-01 | 2050-01-01 | 96, 38 | 0.37d | 0d | start no earlier than 2016-01-01 | Technology |
| 98 | 10.4.5 | MS | milestone | 0mo | 2050-01-01 | 2050-01-01 | 97 | 0.37d |  | finish no earlier than 2018-01-01 | Technology |
| 99 | 10.5 | Robotics / Mechatronics in transfer (MS) | milestone | 0mo | 2041-01-01 | 2041-01-01 | 71, 79 | 3347.64d |  | finish no earlier than 2035-01-01 | Technology |
| 100 | 11 | **ICT based management** |  | 5456.6d | 2015-06-01 | 2030-01-31 |  | 7409.37d |  |  | Technology |
| 101 | 11.1 | **Passenger - ICT based management in real time** |  | 5208d | 2016-01-01 | 2029-12-31 |  | 7440.37d |  |  | Technology |
| 102 | 11.1.1 | Evaluation of existing concepts, technologies and solutions |  | 12mo | 2016-01-01 | 2016-12-31 |  | 7440.37d | 0d | start no earlier than 2016-01-01 | Technology |
| 103 | 11.1.2 | Elaboration and deduction of comprehensive concepts for future ICT-based management, service offers and train path planning |  | 12mo | 2016-12-31 | 2017-12-31 | 102 | 7440.37d | 0d |  | Technology |
| 104 | 11.1.3 | Development of migration and implementation plans |  | 24mo | 2017-12-31 | 2020-01-01 | 103 | 7440.37d | 0d |  | Technology |
| 105 | 11.1.4 | Specification and agreement of harmonised/standardised concepts |  | 18mo | 2020-01-01 | 2021-07-02 | 104 | 7440.37d | 0d |  | Technology |
| 106 | 11.1.5 | Optimisation of existing software tools and/or development of new tools |  | 48mo | 2020-12-31 | 2024-12-31 | 105SS+12mo | 7440.37d | 0d |  | Technology |
| 107 | 11.1.6 | International-coordinated and agreed stepwise implementation |  | 60mo | 2024-12-31 | 2029-12-31 | 106 | 7440.37d | 0d |  | Technology |
| 108 | 11.1.7 | MS | milestone | 0mo | 2029-12-31 | 2029-12-31 | 107 | 7440.37d |  |  | Technology |
| 109 | 11.2 | **Freight - ICT based management in real time** |  | 5208d | 2016-01-01 | 2029-12-31 |  | 7440.37d |  |  | Technology |
| 110 | 11.2.1 | Investigation and evaluation of existing concepts, technologies and solutions |  | 12mo | 2016-01-01 | 2016-12-31 |  | 7440.37d | 0d | start no earlier than 2016-01-01 | Technology |
| 111 | 11.2.2 | Elaboration and deduction of comprehensive concepts for future ICT-based management |  | 12mo | 2016-12-31 | 2017-12-31 | 110 | 7440.37d | 0d |  | Technology |
| 112 | 11.2.3 | Development of migration and implementation plans |  | 24mo | 2017-12-31 | 2020-01-01 | 111 | 7440.37d | 0d |  | Technology |
| 113 | 11.2.4 | Specification and agreement of harmonised/standardised concepts |  | 18mo | 2020-01-01 | 2021-07-02 | 112 | 7440.37d | 0d |  | Technology |
| 114 | 11.2.5 | Optimisation of existing software tools and/or development of new tools |  | 48mo | 2020-12-31 | 2024-12-31 | 113SS+12mo | 7440.37d | 0d |  | Technology |
| 115 | 11.2.6 | International-coordinated and agreed stepwise implementation |  | 60mo | 2024-12-31 | 2029-12-31 | 114 | 7440.37d | 0d |  | Technology |
| 116 | 11.2.7 | MS | milestone | 0mo | 2029-12-31 | 2029-12-31 | 115 | 7440.37d |  |  | Technology |

Notes:
- 94: Evaluation of existing technologies and concepts, deduction of optimisation based on the findings/results of the introduction of ACBC in European rail freight services
- 95: Investigation of usability and technical-economical evaluation for selected marshalling yards of European importance
- 96: Specification of requirements, development of components/technologies and concepts for migration/implementation for selected marshalling yards of European importance in combination with the results/findings of migration/implementation of ACBC and agreement on an international-coordinated implementation plan
- 97: Stepwise implementation of technology and migration to automation of selected marshalling yards of European importance in combination with the implementation/migration of ACBC
- 102: Comprehensive investigation and evaluation of existing concepts, technologies and solutions (soft- and hardware) for ICT-based management of rail passenger services, rail freight services and network management
- 103: Elaboration and deduction of comprehensive concepts for future ICT-based management of rail passenger and freight operations as well as service offers in combination with an integrated ICT-based management of train path planning and network operation
- 104: Development of an international and/or international-coordinated national migration and implementation plans
- 105: Specification and agreement of harmonised/standardised concepts for European-wide unified data exchange and communication between all stakeholders (railway undertakings, intermodal operators, infrastructure managers, etc.)
- 106: Optimisation of existing software tools and/or development of new tools/supplementing components for a comprehensive and integrated ICT-based management of all rail services, infrastructure and operations by the industry in combination with the respective stakeholders
- 107: International-coordinated and agreed stepwise implementation of ICT-based management tools in the European railway area (stakeholders and infrastructure managers)
- 110: Comprehensive investigation and evaluation of existing concepts, technologies and solutions (soft- and hardware) for ICT-based management of rail passenger services, rail freight services and network management
- 111: Elaboration and deduction of comprehensive concepts for future ICT-based management of rail passenger and freight operations as well as service offers in combination with an integrated ICT-based management of train path planning and network operation
- 112: Development of an international and/or international-coordinated national migration and implementation plans
- 113: Specification and agreement of harmonised/standardised concepts for European-wide unified data exchange and communication between all stakeholders (railway undertakings, intermodal operators, infrastructure managers, etc.)
- 114: Optimisation of existing software tools and/or development of new tools/supplementing components for a comprehensive and integrated ICT-based management of all rail services, infrastructure and operations by the industry in combination with the respective stakeholders
- 115: International-coordinated and agreed stepwise implementation of ICT-based management tools in the European railway area (stakeholders and infrastructure managers)

| ID | WBS | Task | Type | Duration | Start | Finish | Predecessors | Total slack | Free slack | Constraint | Action Field |
| --- | --- | --- | --- | --- | --- | --- | --- | --- | --- | --- | --- |
| 117 | 11.3 | **Galileo** |  | 2078.24d | 2015-06-01 | 2021-01-01 |  | 10787.7d |  |  | Technology |
| 118 | 11.3.1 | Realisation of Galileo |  | 67.04mo | 2015-06-01 | 2021-01-01 |  | 10787.7d | 0d |  | Technology |
| 119 | 11.3.2 | MS | milestone | 0mo | 2021-01-01 | 2021-01-01 | 118 | 10787.7d |  |  | Technology |
| 120 | 11.4 | **Comprehensive ICT based management and operations / e-solutions** |  | 5239d | 2016-01-01 | 2030-01-31 |  | 7409.37d |  |  | Technology |
| 121 | 11.4.1 | Agreement on and development of a common concept for unified data exchange |  | 48mo | 2016-01-01 | 2020-01-01 |  | 7409.37d | 0d | start no earlier than 2016-01-01 | Technology |
| 122 | 11.4.2 | MS | milestone | 0mo | 2020-01-01 | 2020-01-01 | 121 | 11160.4d |  |  | Technology |
| 123 | 11.4.3 | Communication and cooperation of all actors for train path and rail freight services along the CNCs |  | 121mo | 2020-01-01 | 2030-01-31 | 121 | 7409.37d | 0d |  | Technology |
| 124 | 11.4.4 | MS | milestone | 0mo | 2030-01-31 | 2030-01-31 | 123 | 7409.37d |  |  | Technology |
| 125 | 12 | **Predictive Maintenance for infrastructure** |  | 8928.15d | 2016-01-01 | 2040-01-01 |  | 3720.22d |  |  | Infrastructure |
| 126 | 12.1 | Investigation and evaluation of existing concepts and available technology |  | 12mo | 2016-01-01 | 2016-12-31 |  | 3720.37d | 0d | start no earlier than 2016-01-01 | Infrastructure |
| 127 | 12.2 | Investigation of the usability and possibilities of predictive maintenance |  | 24mo | 2016-12-31 | 2018-12-31 | 126 | 3720.37d | 0.15d |  | Infrastructure |
| 128 | 12.3 | Deduction, specification and technical-economical evaluation |  | 18mo | 2019-01-01 | 2020-07-01 | 127 | 3720.22d | 0d | start no earlier than 2019-01-01 | Infrastructure |
| 129 | 12.4 | Elaboration of recommendations for development and implementation |  | 30mo | 2020-07-01 | 2023-01-01 | 128 | 3720.22d | 0d | start no earlier than 2019-01-01 | Infrastructure |
| 130 | 12.5 | Development of suitable technologies |  | 36mo | 2023-01-01 | 2025-12-31 | 129 | 3720.22d | 0d |  | Infrastructure |
| 131 | 12.6 | Stepwise implementation in the European CNC |  | 168mo | 2025-12-31 | 2040-01-01 | 130 | 3720.22d | 0d | start no earlier than 2016-01-01 | Infrastructure |
| 132 | 12.7 | MS | milestone | 0mo | 2040-01-01 | 2040-01-01 | 131 | 3720.22d |  | start no earlier than 2015-06-01 | Infrastructure |
| 133 | 13 | **Interoperability, modular design** |  | 8928d | 2016-01-01 | 2040-01-01 |  | 3720.37d |  |  | Infrastructure |
| 134 | 13.1 | **ETCS Level 3** |  | 8928d | 2016-01-01 | 2040-01-01 |  | 3720.37d | 0d |  | Infrastructure |
| 135 | 13.1.1 | Evaluation of technology for ETCS Level 3 |  | 24mo | 2016-01-01 | 2017-12-31 |  | 3720.37d | 0d | start no earlier than 2016-01-01 | Infrastructure |
| 136 | 13.1.2 | Comprehensive technical-economical evaluation |  | 36mo | 2017-12-31 | 2020-12-31 | 135 | 3720.37d | 0d | start no earlier than 2016-06-01 | Infrastructure |
| 137 | 13.1.3 | Elaboration and specification of a pan-European standardised technology |  | 36mo | 2020-12-31 | 2024-01-01 | 136 | 3720.37d | 0d | start no earlier than 2017-01-01 | Infrastructure |
| 138 | 13.1.4 | European Agreement on the specification |  | 18mo | 2024-01-01 | 2025-07-02 | 137 | 3720.37d | 0d | start no earlier than 2017-01-01 | Infrastructure |
| 139 | 13.1.5 | Agreement of cost units |  | 24mo | 2025-07-02 | 2027-07-02 | 138 | 3720.37d | 0d | start no earlier than 2017-01-01 | Infrastructure |
| 140 | 13.1.6 | Agreement on implementation plan |  | 30mo | 2027-07-02 | 2029-12-31 | 139 | 3720.37d | 0d | start no earlier than 2017-01-01 | Infrastructure |
| 141 | 13.1.7 | Coordinated implementation on European CNC |  | 120mo | 2029-12-31 | 2040-01-01 | 140, 178SS | 3720.37d | 0d | start no earlier than 2018-01-01 | Infrastructure |
| 142 | 13.1.8 | MS | milestone | 0mo | 2040-01-01 | 2040-01-01 | 141 | 3720.37d |  | start no earlier than 2015-06-01 | Infrastructure |
| 143 | 13.2 | Modular design | milestone | 0mo | 2025-01-01 | 2025-01-01 |  | 9298.9d |  | finish no earlier than 2025-01-01 | Infrastructure |

Notes:
- 118: International-coordinated and agreed stepwise implementation of ICT-based management tools in the European railway area (stakeholders and infrastructure managers)
- 120: ·Introduction of an holistic ICT based CNC-management for train path planning and operation as well as an comprehensive ICT based planning and monitoring of rail freight services including all actors of the transport chain. / ·Agreement on and development of a common concept for unified data exchange until 2020. / ·Communication and cooperation of all actors for train path and rail freight services along the CNCs until 2030.
- 126: Investigation and evaluation of existing concepts and available technology tools/components for predictive maintenance of rail infrastructure by the industry
- 127: Investigation of the usability and possibilities for predictive maintenance of the different parts and components of the railway network by the infrastructure managers
- 128: Deduction, specification and technical-economical evaluation of respective concepts and related technologies by the industry in coordination with the infrastructure managers
- 129: Elaboration of international-agreed recommendations for development and implementation of respective technologies by infrastructure managers
- 130: Development of suitable technologies by the industry based on the specifications of the IMs
- 131: Stepwise implementation in the European CNC by national IMs based on international agreements
- 134: ·Development and implementation of an European wide harmonised/updated ETCS Level 3 technology. / ·Finalisation of development until 2020 under consideration of alternative/complementary technology options for moving block-based rail operation and elaboration of an implementation plan until 2025 based on the experiences with the implementation of ETCS Level 2 on CNC. / ·Implementation on the CNC in the timeframe 2025-2040.
- 135: Evaluation of the state of the art technology for ETCS Level 3 and deduction of potential for optimisation
- 136: Comprehensive technical-economical evaluation of a mid-term implementation of optimised ETCS Level 3 on the CNC based on mid- to long-term requirements for the train path demand
- 137: Elaboration and specification of a pan-European standardised technology (soft- and hardware) for ETCS Level 3
- 138: European Agreement on the specification as basis for the final industrial development of technology and software
- 139: Agreement of costs for the procurement of technology and software between IMs and the industry as basis for the development of an international-coordinated implementation plan on the CNC
- 140: Agreement between the EC and the respective member states on implementation plan recommended by the IMs
- 141: Coordinated implementation on European CNC
- 143: Continuous process (see Guide Book)

| ID | WBS | Task | Type | Duration | Start | Finish | Predecessors | Total slack | Free slack | Constraint | Action Field |
| --- | --- | --- | --- | --- | --- | --- | --- | --- | --- | --- | --- |
| 144 | 13.3 | **Gauge C (4m high)** |  | 8928d | 2016-01-01 | 2040-01-01 |  | 3720.37d |  |  | Infrastructure |
| 145 | 13.3.1 | Investigation of existing restrictions on the European rail network |  | 18mo | 2016-01-01 | 2017-07-01 |  | 3720.37d | 0d | start no earlier than 2016-01-01 | Infrastructure |
| 146 | 13.3.2 | Elaboration of requirements for the transport of 4m-trailers |  | 18mo | 2016-12-31 | 2018-07-02 | 145SS+12mo | 3720.37d | 0d | start no earlier than 2016-01-01 | Infrastructure |
| 147 | 13.3.3 | Analysis and technical-economical evaluation of existing technologies |  | 18mo | 2017-07-01 | 2018-12-31 | 146SS+6mo | 3720.37d | 0d | start no earlier than 2016-01-01 | Infrastructure |
| 148 | 13.3.4 | Evaluation of findings/results |  | 12mo | 2018-12-31 | 2020-01-01 | 147 | 3720.37d | 0d | start no earlier than 2016-01-01 | Infrastructure |
| 149 | 13.3.5 | Deduction of an international-coordinated plan |  | 18mo | 2020-01-01 | 2021-07-02 | 148 | 3720.37d | 0d | start no earlier than 2016-01-01 | Infrastructure |
| 150 | 13.3.6 | Agreement on EC-coordinated alleviation plan for the CNC and comprehensive network |  | 30mo | 2021-07-02 | 2024-01-01 | 149 | 3720.37d | 0d | start no earlier than 2016-01-01 | Infrastructure |
| 151 | 13.3.7 | Upgrading of the CNC based on the alleviation plan |  | 72mo | 2024-01-01 | 2029-12-31 | 150 | 3720.37d | 0d | start no earlier than 2016-01-01 | Infrastructure |
| 152 | 13.3.8 | Upgrading of the Comprehensive network based on the alleviation plan |  | 120mo | 2029-12-31 | 2040-01-01 | 151 | 3720.37d | 0d | start no earlier than 2016-01-01 | Infrastructure |
| 153 | 13.3.9 | MS | milestone | 0mo | 2040-01-01 | 2040-01-01 | 152 | 3720.37d |  | start no earlier than 2015-06-01 | Infrastructure |
| 154 | 14 | **EU Network development** |  | 9175.21d | 2015-06-01 | 2040-01-30 |  | 3690.76d |  |  | Infrastructure |
| 155 | 14.1 | **Network upgrading** |  | 3720.59d | 2020-01-01 | 2030-01-01 |  | 7439.91d | 0d |  | Infrastructure |
| 156 | 14.1.1 | Freight train lenght --> 750m (especially in south and south east Europe) |  | 60mo | 2020-01-01 | 2024-12-31 |  | 9300.51d |  | start no earlier than 2020-01-01 | Infrastructure |
| 157 | 14.1.2 | Freight train lenght --> Stepwise implementation 1500m (especially on corridors in central Europe with significant importance for freight) |  | 60mo | 2025-01-01 | 2030-01-01 |  | 7439.91d | 0d | start no earlier than 2025-01-01 | Infrastructure |
| 158 | 14.1.3 | MS | milestone | 0mo | 2030-01-01 | 2030-01-01 | 157 | 7439.91d |  | start no earlier than 2015-06-01 | Infrastructure |
| 159 | 14.2 | **New lines** |  | 9145d | 2015-07-01 | 2040-01-30 |  | 3690.76d |  |  | Infrastructure |
| 160 | 14.2.1 | TEN-T and Bottlenecks elimination |  | 168mo | 2016-01-01 | 2029-12-31 | 218SS | 7440.37d |  | start no earlier than 2016-01-01 |  |
| 161 | 14.2.2 | **Targeted bypasses for freight in metropolitan and congested areas (based on respective investigations)** |  | 9145d | 2015-07-01 | 2040-01-30 |  | 3690.76d |  |  | Infrastructure |
| 162 | 14.2.2.1 | Realisation of investigations |  | 55mo | 2015-07-01 | 2020-01-30 |  | 3690.76d | 0d | start no earlier than 2015-07-01 | Infrastructure |
| 163 | 14.2.2.2 | Concept for implementation |  | 60mo | 2020-01-30 | 2025-01-29 | 162 | 3690.76d | 0d | start no earlier than 2020-01-01 | Infrastructure |
| 164 | 14.2.2.3 | Stepwise realisation |  | 180mo | 2025-01-29 | 2040-01-30 | 163 | 3690.76d | 0d | start no earlier than 2020-01-01 | Infrastructure |
| 165 | 14.2.2.4 | MS | milestone | 0mo | 2040-01-30 | 2040-01-30 | 164 | 3690.76d |  | start no earlier than 2015-06-01 | Infrastructure |
| 166 | 14.2.3 | **Long distance passenger network** |  | 5239d | 2016-01-01 | 2030-01-31 |  | 7409.37d |  |  | Infrastructure |
| 167 | 14.2.3.1 | Coordination of national plans (bi/tri-lateral international) for long distance passenger network |  | 169mo | 2016-01-01 | 2030-01-31 |  | 7409.37d |  | start no earlier than 2016-01-01 | Infrastructure |
| 168 | 14.2.3.2 | 20,000 km HSR and upgraded lines in operation |  | 169mo | 2016-01-01 | 2030-01-31 |  | 7409.37d |  | start no earlier than 2016-01-01 | Infrastructure |
| 169 | 14.2.4 | Investment plan for the time 2030 to 2050 is defined (MS) | milestone | 0mo | 2029-12-01 | 2029-12-01 |  | 7470.89d |  | finish no earlier than 2029-12-01 | Infrastructure |
| 170 | 14.3 | Optimisation of operations |  | 60mo | 2015-06-01 | 2020-05-31 |  | 11006d |  |  | Infrastructure |
| 171 | 14.4 | Elimination of bottlenecks |  | 60mo | 2015-06-01 | 2020-05-31 |  | 11006d |  |  | Infrastructure |
| 172 | 14.5 | New urban rail lines |  | 60mo | 2015-06-01 | 2020-05-31 |  | 11006d |  |  | Infrastructure |

Notes:
- 145: Investigation of restrictions in the existing European rail network (CNC and comprehensive network) for seamless transport of 4m-trailers in intermodal services
- 146: Elaboration of mid- to long- term requirements for the transport of 4m-trailers in the European rail network based on the developing market demand
- 147: Analysis and technical-economical evaluation of existing technologies for trailer transport in European intermodal services in combination with infrastructure requirements (terminals and network)
- 148: Evaluation of findings/results, agreement between stakeholders and infrastructure managers about mid- to long-term requirements improving the CNC and comprehensive network for the availability of 4m-trailer transport
- 149: Deduction of an international-coordinated plan for the improvement of the European rail infrastructure for seamless 4m-trailer transport
- 150: Agreement on EC-coordinated alleviation plan for the CNC and comprehensive network between stakeholders, IMs and member states
- 151: Upgrading of the CNC based on the alleviation plan
- 152: Upgrading of the Comprehensive network based on the alleviation plan

| ID | WBS | Task | Type | Duration | Start | Finish | Predecessors | Total slack | Free slack | Constraint | Action Field |
| --- | --- | --- | --- | --- | --- | --- | --- | --- | --- | --- | --- |
| 173 | 14.6 | **New EU Network development plan** |  | 3347.71d | 2017-01-01 | 2026-01-01 |  | 8555.64d |  |  | Infrastructure |
| 174 | 14.6.1 | Investigation of the requirements of the development of the EU rail network |  | 36mo | 2018-01-01 | 2020-12-31 |  | 10787.9d |  | start no earlier than 2018-01-01 | Infrastructure |
| 175 | 14.6.2 | Technical-economical evaluation of optimised train length in the different parts of the European rail network |  | 36mo | 2017-01-01 | 2020-01-01 |  | 11159.6d |  | start no earlier than 2017-01-01 | Infrastructure |
| 176 | 14.6.3 | Investigation of the requirements for additional lines |  | 30mo | 2018-06-01 | 2020-11-30 |  | 10820.1d |  | start no earlier than 2018-06-01 | Infrastructure |
| 177 | 14.6.4 | Investigation and evaluation of the foreseen HSR network |  | 30mo | 2018-06-01 | 2020-11-30 |  | 10261.1d | 0d | start no earlier than 2018-06-01 | Infrastructure |
| 178 | 14.6.5 | Investigation and evaluation of current rail operations on the CNC and deduction of optimisations for new operation schemes |  | 36mo | 2018-01-01 | 2020-12-31 |  | 8183.93d | 0d | start no earlier than 2018-01-01 | Infrastructure |
| 179 | 14.6.6 | Elaboration of an international-coordinated new long-term development plan of the EU rail network |  | 60mo | 2020-12-31 | 2026-01-01 | 178 | 8927.93d | 0d | start no earlier than 2018-01-01 | Infrastructure |
| 180 | 14.6.7 | MS | milestone | 0mo | 2026-01-01 | 2026-01-01 | 179 | 8927.93d |  | start no earlier than 2015-06-01 | Infrastructure |
| 181 | 15 | **Safety & Security, Environment and sustainability** |  | 7440d | 2015-06-01 | 2035-06-02 |  | 5425.97d |  |  | Infrastructure |
| 182 | 15.1 | Noise protection |  | 240mo | 2015-06-01 | 2035-06-02 |  | 5425.97d |  |  | Infrastructure |
| 183 | 16 | **Stations** |  | 11378.8d? | 2015-06-01 | 2046-01-02 |  | 1487.2d |  |  | Infrastructure |
| 184 | 16.1 | **Stations, city hubs & last mile** |  | 11160.2d | 2016-01-01 | 2046-01-01 |  | 1487.2d | 0d |  | Infrastructure |
| 185 | 16.1.1 | Elaboration of a catalogue of blueprints for stations |  | 30mo | 2016-01-01 | 2018-07-02 |  | 10415.4d | 0d | start no earlier than 2016-01-01 | Infrastructure |
| 186 | 16.1.2 | Including the catalogue/guidelines in the existent regulations |  | 18mo | 2018-07-02 | 2020-01-01 | 185 | 10415.4d | 371.86d | start no earlier than 2018-07-02 | Infrastructure |
| 187 | 16.1.3 | Development of corridor-specific/national plans for the improvement of the electrified rail access |  | 36mo | 2020-01-01 | 2022-12-31 | 186SS+6mo | 10043.5d |  | start no earlier than 2020-01-01 | Infrastructure |
| 188 | 16.1.4 | Technical-economical evaluation of air-rail connections and respective actions |  | 24mo | 2020-05-31 | 2022-06-01 | 177SS+24mo | 10261.1d |  | start no earlier than 2019-01-01 | Infrastructure |
| 189 | 16.1.5 | Deduction of and agreement on an implementation plan |  | 36mo | 2023-01-01 | 2025-12-31 |  | 1487.36d | 0.15d | start no earlier than 2023-01-01 | Infrastructure |
| 190 | 16.1.6 | Realisation of the implementation plan on the CNC |  | 120mo | 2026-01-01 | 2036-01-01 | 189 | 1487.2d | 0d | start no earlier than 2026-01-01 | Infrastructure |
| 191 | 16.1.7 | Realisation of the implementation plan on the comprehensive network |  | 120mo | 2036-01-01 | 2046-01-01 | 190 | 1487.2d |  | start no earlier than 2030-01-01 | Infrastructure |
| 192 | 16.2 | Station service offerings | milestone | 0mo | 2020-01-01 | 2020-01-01 |  | 11159.5d |  | finish no earlier than 2020-01-01 | Infrastructure |
| 193 | 16.3 | Connection between airports and city centres |  | 95.99mo | 2017-01-01 | 2024-12-31 |  | 9299.95d |  | start no earlier than 2017-01-01 | Infrastructure |
| 194 | 16.4 | Connections between airports and HSR stations |  | 95.99mo | 2018-01-01 | 2025-12-31 |  | 8928.24d |  | start no earlier than 2018-01-01 | Infrastructure |
| 195 | 16.5 | Passenger urban last mile related network and DTD integration (MS) | milestone | 0mo | 2015-06-01 | 2015-06-01 |  | 12866d |  |  | Infrastructure |
| 196 | 16.6 | MS | milestone | 0.03mo? | 2046-01-01 | 2046-01-02 | 184 | 1487.2d |  |  | Infrastructure |

Notes:
- 174: Investigation of the mid- to long-term requirements of the development of the EU rail network based on the existent and ongoing studies, agreements and plans for the improvement of the European CNC regarding network upgrading (e.g. train length, bottleneck elimination, new lines) in combination with the targeted shift to rail.
- 175: Technical-economical evaluation of optimised train length in the different parts of the European rail network based on the expected mid- to long-term market demand for rail freight services, targeted shift to rail and train path availability
- 176: Investigation of the requirements for additional lines (e.g. bypasses in congested areas, new/extended commuter services) according to the targeted shift to rail / Beschreibung: (e.g. bypasses in congested areas, new/extended commuter services)
- 177: Investigation and evaluation of the foreseen improvement of the European HSR network mirroring the structure of the mid- to long-term development of the market demand and targeted shift to rail
- 178: Investigation and evaluation of current rail operations on the CNC and deduction of suitable optimisations for new operation schemes (e.g. flying overtaking in combination with infrastructure upgrading) also as input for ICT based management of the network and the implementation plans for ETCS Level 3
- 179: Elaboration and evaluation of an international-coordinated new long-term development plan of the EU rail network in addition to the existing and ongoing development plans for the European rail network targeted to the desired shift to rail
- 185: Elaboration of a catalogue of blueprints for stations of the future as a guideline; considering the requirements for a multimodal mobility based on electrified rail (Design concepts and services profiles) including examples for good practices.
- 186: Including the catalogue/guidelines in the existent regulations for the TEN-T corridors (1st step) and comprehensive network (2nd step) in form of European recommendations for the upgrading of stations under national responsibilities (public authorities/stakeholders)
- 187: Development of corridor-specific/national plans for the improvement of the electrified rail access by studies including regional investigations for the expansion and adaption of respective stations
- 188: Technical-economical evaluation of the holistic integration of the European HSR network with the European air hubs (1st step) and in a second step linking of all important airports to rail. To be done in combination with 9.1.4
- 189: Deduction of and agreement on an implementation plan for the Improvement of important stations on CNC (1st step) and on the comprehensive network (2nd step).
- 190: Realisation of the implementation plan on the CNC under respective national responsibilities
- 191: Realisation of the implementation plan on the comprehensive network under respective national responsibilities.
- 192: See Guide Book

| ID | WBS | Task | Type | Duration | Start | Finish | Predecessors | Total slack | Free slack | Constraint | Action Field |
| --- | --- | --- | --- | --- | --- | --- | --- | --- | --- | --- | --- |
| 197 | 17 | **Nodes** |  | 8555.75d? | 2016-01-01 | 2039-01-01 |  | 4092.63d |  |  | Infrastructure |
| 198 | 17.1 | Identification of freight traffic attraction zones along the European CNC |  | 24mo | 2016-01-01 | 2017-12-31 |  | 11904.4d |  | start no earlier than 2016-01-01 | Infrastructure |
| 199 | 17.2 | Analysis and definition of future requirements |  | 24mo | 2016-01-01 | 2017-12-31 |  | 11904.4d |  | start no earlier than 2016-01-01 | Infrastructure |
| 200 | 17.3 | Catalogue of Blueprints for service profiles and respective design concepts |  | 30mo | 2020-01-01 | 2022-07-02 | 64, 65, 66 | 4463.37d | 0d | start no earlier than 2018-01-01 | Infrastructure |
| 201 | 17.4 | Plans for the improvement of rail freight nodes |  | 24mo | 2022-07-02 | 2024-07-01 | 200 | 4463.37d | 0d | start no earlier than 2020-07-01 | Infrastructure |
| 202 | 17.5 | European-wide implementation plan |  | 18mo | 2024-07-01 | 2025-12-31 | 201 | 4463.37d | 0d | start no earlier than 2022-07-01 | Infrastructure |
| 203 | 17.6 | Realisation of the implementation plan under national responsibilities |  | 144mo | 2025-12-31 | 2038-01-01 | 202 | 4463.37d | 0d | start no earlier than 2024-01-01 | Infrastructure |
| 204 | 17.7 | MS | milestone | 0.03mo? | 2038-01-01 | 2038-01-02 | 203 | 4463.37d |  |  | Infrastructure |
| 205 | 17.8 | **Network nodes positioning and role** |  | 3348d | 2017-12-31 | 2027-01-01 | 278SS+24mo | 8556.37d |  |  | Infrastructure |
| 206 | 17.8.1 | Analysis of european traffic attraction zones under consideration of their future development |  | 48mo | 2017-12-31 | 2021-12-31 |  | 8556.37d | 0d | start no earlier than 2016-01-01 | Infrastructure |
| 207 | 17.8.2 | Evaluation of the current network of rail freight nodes |  | 60mo | 2021-12-31 | 2027-01-01 | 206 | 8556.37d |  | start no earlier than 2016-07-01 | Infrastructure |
| 208 | 17.8.3 | European-wide coordinated, comprehensive development plan for rail freight nodes |  | 48mo | 2020-01-01 | 2024-01-01 |  | 9672.51d |  | start no earlier than 2020-01-01 | Infrastructure |
| 209 | 17.8.4 | Realisation of elaborated recommendations |  | 12mo | 2020-01-01 | 2020-12-31 |  | 10788.5d |  | start no earlier than 2020-01-01 | Infrastructure |
| 210 | 17.9 | Co-modal integration and nodes accessibility (MS) | milestone | 0mo | 2025-01-01 | 2025-01-01 |  | 9298.9d |  | finish no earlier than 2025-01-01 | Infrastructure |
| 211 | 17.10 | Freight urban last mile related network and DTD integration (MS) | milestone | 0mo | 2030-01-01 | 2030-01-01 |  | 7439.32d |  | finish no earlier than 2030-01-01 | Infrastructure |
| 212 | 17.11 | **12.4 East freight interchanges** |  | 5207.29d | 2025-01-01 | 2039-01-01 |  | 4092.63d |  |  | Infrastructure |
| 213 | 17.11.1 | Analysis of existing East freight interchanges, considering their future development |  | 24mo | 2025-01-01 | 2027-01-01 |  | 5579.91d | 1487.29d | start no earlier than 2025-01-01 | Infrastructure |
| 214 | 17.11.2 | Development plan including the integration of East freight interchanges into European CNC |  | 36mo | 2031-01-01 | 2033-12-31 | 213 | 4092.63d | 0d | start no earlier than 2031-01-01 | Infrastructure |
| 215 | 17.11.3 | Realisation of the development plan |  | 60mo | 2033-12-31 | 2039-01-01 | 214 | 4092.63d | 0d |  | Infrastructure |
| 216 | 17.11.4 | MS | milestone | 0mo | 2039-01-01 | 2039-01-01 | 215 | 4092.63d |  | start no earlier than 2020-10-01 | Infrastructure |
| 217 | 17.12 | Sea ports, hubs, freight villages, industrial parks, dry ports | milestone | 0mo | 2030-01-01 | 2030-01-01 |  | 7439.32d |  | finish no earlier than 2030-01-01 | Infrastructure |
| 218 | 18 | **Network governance** |  | 5209.05d | 2016-01-01 | 2030-01-01 |  | 7439.32d | 0d |  | Governance |
| 219 | 18.1 | Analysis of Requirements |  | 18mo | 2016-01-01 | 2017-07-01 |  | 10602.4d | 371.06d | start no earlier than 2016-01-01 | Governance |
| 220 | 18.2 | Agreement on important fields and deduction of respective guidelines |  | 18mo | 2017-07-01 | 2018-12-30 | 219SS+6mo | 10231.3d | 187.09d | start no earlier than 2017-07-01 | Governance |
| 221 | 18.3 | Specification of harmonised standards |  | 24mo | 2019-01-01 | 2020-12-31 | 220SS+12mo | 10044.2d | 0.44d | start no earlier than 2019-01-01 | Governance |
| 222 | 18.4 | Agreement on and implementation of respective European bodies for governance |  | 24mo | 2021-01-01 | 2023-01-01 | 221 | 10043.8d |  | start no earlier than 2021-01-01 | Governance |
| 223 | 18.5 | Analysis of the requirement and objectives for regional and local masterplans & deduction of respective guidelines |  | 24mo | 2016-01-01 | 2017-12-31 |  | 11904.4d |  | start no earlier than 2016-01-01 | Governance |
| 224 | 18.6 | Analysis of the requirement and objectives for sustainable urban mobility plans & deduction of respective guidelines |  | 24mo | 2016-01-01 | 2017-12-31 |  | 11904.4d |  | start no earlier than 2016-01-01 | Governance |

Notes:
- 198: Identification of important freight traffic attraction zones along the European CNC under consideration of the forecasted development for the transport and logistic demand
- 199: Analysis and definition of future requirements for the service profile and network integration of nodes for rail based supply and distribution chains and recommended solutions for last mile services. Indentification of respective existing good practices.
- 200: Elaboration of a catalogue of blueprints for service profiles and respective design concepts tailored to the regional structure of demand as a guideline; considering the requirements for rail-based multimodal transport chains including regional access points/networks for urban logistics based on electrified rail. Considering the results of 5.1
- 201: Development of corridor-specific/national plans for the improvement of the rail freight nodes by studies including regional investigations for the adaption and upgrading of existing as well as a development plan for new rail freight nodes in the traffic attraction zones.
- 202: Elaboration of a European-wide coordinated, comprehensive implementation plan for the identified rail freight nodes based on the catalogue of blueprints.
- 206: European development and implementation plan for a high performance terminal network coveríng all main freight attraction zones
- 208: Elaboration of a European-wide coordinated, comprehensive development plan for rail freight nodes based on the comparison of previous results and the identification of current and future gaps
- 210: See Guide Book
- 211: See Guide Book
- 214: Elaboration of a development plan including the integration of East freight interchanges into European CNC
- 217: See SPIDER PLUS Guide Book
- 219: Analysis of the requirement and objectives for a holistic governance of the development of the European rail infrastructure for freight and passenger services based on the existing regulations for the exploitation of the TEN-T considering the vision 2050 for sustainable mobility and the derived infrastructure vision components.
- 220: Agreement on important fields for governance and deduction of respective guidelines for a holistic field respective governance concept ensuring investment effectiveness coordinated planning, technological development and market uptake.
- 221: Specification of harmonised standards and guidelines in the framework of the TEN-T realisation for the European railports network, compatibility of the capacity of terminals/hubs on the corridor in line with train path capacity and the desired single EU rail space.
- 222: Agreement on / and implementation of respective European bodies for governance
- 223: Analysis of the requirement and objectives for regional and local masterplans in favour of rail for door to door transport services as well as deduction of respective guidelines for an implementation under national responsibilities by European coordination
- 224: Analysis of the requirement and objectives for sustainable urban mobility plans in favour of rail for door to door transport services as well as deduction of respective guidelines for an implementation under national responsibilities by European coordination

| ID | WBS | Task | Type | Duration | Start | Finish | Predecessors | Total slack | Free slack | Constraint | Action Field |
| --- | --- | --- | --- | --- | --- | --- | --- | --- | --- | --- | --- |
| 225 | 18.7 | **European railport network** |  | 1860d | 2025-01-01 | 2030-01-01 | 278SS+24mo | 7439.91d |  |  | Governance |
| 226 | 18.7.1 | Development of an European railport/freight-village network |  | 60mo | 2025-01-01 | 2030-01-01 |  | 7439.91d |  | start no earlier than 2025-01-01 | Governance |
| 227 | 18.8 | Infrastructure integration in space planning (MS) | milestone | 0mo | 2025-01-01 | 2025-01-01 |  | 9298.9d |  | finish no earlier than 2025-01-01 | Governance |
| 228 | 18.9 | European model for transport authorities (MS) | milestone | 0mo | 2030-01-01 | 2030-01-01 |  | 7439.32d |  | finish no earlier than 2030-01-01 | Governance |
| 229 | 18.10 | Regional and local Master Plans in favour of rail and DTD integration (MS) | milestone | 0mo | 2030-01-01 | 2030-01-01 |  | 7439.32d |  | finish no earlier than 2030-01-01 | Governance |
| 230 | 18.11 | Sustainable urban mobility plans (SUMP) (MS) | milestone | 0mo | 2030-01-01 | 2030-01-01 |  | 7439.32d |  | finish no earlier than 2030-01-01 | Governance |
| 231 | 18.12 | Capacity of hubs compatible with corridor capacity (MS) | milestone | 0mo | 2030-01-01 | 2030-01-01 |  | 7439.32d |  | finish no earlier than 2030-01-01 | Governance |
| 232 | 18.13 | **TEN-T Realisation** |  | 1860d | 2025-01-01 | 2030-01-01 |  | 7439.91d |  |  | Governance |
| 233 | 18.13.1 | Holistic coordination/management along CNC of all infrastructure |  | 60mo | 2025-01-01 | 2030-01-01 |  | 7439.91d |  | start no earlier than 2025-01-01 | Governance |
| 234 | 19 | **Transport Industrialisation** |  | 12648d | 2016-01-01 | 2050-01-01 |  | 0.32d |  |  | Governance |
| 235 | 19.1 | Requirements and objectives of a European governance |  | 30mo | 2016-01-01 | 2018-07-02 |  | 9858.37d | 0d | start no earlier than 2016-01-01 | Governance |
| 236 | 19.2 | Specification of objectives and guidelines (Freight) |  | 24mo | 2018-07-02 | 2020-07-01 | 235 | 9858.37d | 0d | start no earlier than 2018-07-01 | Governance |
| 237 | 19.3 | Specification of objectives and guidelines (Passenger) |  | 24mo | 2018-07-02 | 2020-07-01 | 235 | 9858.37d | 0d | start no earlier than 2018-07-01 | Governance |
| 238 | 19.4 | Specification of objectives and guidelines (Operation) |  | 24mo | 2018-07-02 | 2020-07-01 | 235 | 9858.37d | 0d | start no earlier than 2018-07-01 | Governance |
| 239 | 19.5 | Specification of objectives and guidelines (ICT) |  | 24mo | 2018-07-02 | 2020-07-01 | 235 | 9858.37d | 0d | start no earlier than 2018-07-01 | Governance |
| 240 | 19.6 | Introduction of H24 T7 |  | 24mo | 2018-07-02 | 2020-07-01 | 235 | 9858.37d | 0d | start no earlier than 2018-07-01 | Governance |
| 241 | 19.7 | Implementation plan for governance actions |  | 36mo | 2020-07-01 | 2023-07-02 | 235, 236, 237, 238, 239, 240 | 9858.37d |  | start no earlier than 2020-07-01 | Governance |
| 242 | 19.8 | Optimized connectivity/Different types of services (MS) | milestone | 0mo | 2050-01-01 | 2050-01-01 | 246 | 0.32d |  | finish no earlier than 2025-01-01 | Governance |
| 243 | 19.9 | Train coupling and sharing of train modules (MS) | milestone | 0mo | 2030-01-01 | 2030-01-01 |  | 7439.32d |  | finish no earlier than 2030-01-01 | Governance |
| 244 | 19.10 | Increasing of train paths per hour (MS) | milestone | 0mo | 2040-01-01 | 2040-01-01 | 134 | 3720.37d |  | finish no earlier than 2030-01-01 | Governance |
| 245 | 19.11 | Longer, commercially faster and heavier trains (MS) | milestone | 0mo | 2030-01-01 | 2030-01-01 | 155 | 7439.91d |  | finish no earlier than 2025-01-01 | Governance |
| 246 | 19.12 | **High frequent services and integrated timetable** |  | 12648d | 2016-01-01 | 2050-01-01 |  | 0.32d | 0d |  | Governance |
| 247 | 19.12.1 | Identification of current good practices |  | 12mo | 2016-01-01 | 2016-12-31 |  | 3968.37d | 248.73d | start no earlier than 2016-01-01 | Governance |
| 248 | 19.12.2 | Regional/National Analysis for the introduction of an integrated timetable |  | 36mo | 2017-01-01 | 2020-01-01 | 247SS+4mo | 3719.64d | 0d | start no earlier than 2017-01-01 | Governance |
| 249 | 19.12.3 | Preparation of the infrastructure |  | 60mo | 2020-01-01 | 2025-01-01 | 248 | 3719.64d | 0d | start no earlier than 2020-01-01 | Governance |
| 250 | 19.12.4 | Stepwise implementation of an integrated timetable |  | 180mo | 2025-01-01 | 2040-01-02 | 249 | 3719.64d |  | start no earlier than 2025-01-01 | Governance |
| 251 | 19.12.5 | Analysis for the introduction of an integrated timetable between main European rail hubs |  | 36mo | 2037-01-01 | 2040-01-01 | 250SS+12mo | 0.32d | 0d | start no earlier than 2037-01-01 | Governance |
| 252 | 19.12.6 | Stepwise implementation of an integrated timetable between main European rail hubs |  | 120mo | 2040-01-01 | 2050-01-01 | 251 | 0.32d |  | start no earlier than 2038-01-01 | Governance |

Notes:
- 227: See Guide Book
- 228: See Guide Book
- 229: See Gudie Book
- 230: See Guide Book
- 231: See Guide Book
- 233: Holistic coordination/management along CNC of all infrastructure (including last mile) and services/operations related to capacity, quality and standardisation until 2030.
- 235: Analysis and identification of the requirement and the objectives of a European governance to support the transistion of European rail freight and passenger services to an improved industrialisation based on the implementation of new technologies, ICT-based management and operational schemes.
- 236: Specification of detailed objectives and guidelines for the governance of the European-wide harmonised implementation of new technologies for rail freight services.
- 237: Specification of detailed objectives and guidelines for the governance of the European-wide harmonised implementation of new technologies for rail passenger services
- 238: Specification of detailed objectives and guidelines for the governance of the European-wide harmonised implementation of new technologies for rail network operation schemes for improved rail freight and passenger train operations
- 239: Specification of detailed objectives and guidelines for the governance of the European-wide harmonised implementation of an coordinated ICT-based management for freight, passenger and network operations as well as information services.
- 240: Agreement on an initiative including all actors and stakeholders for a future European-wide introduction of H24 T7 working cycles in all logistic and transport areas involved in the distribution and supply chain.
- 241: Deduction and agreement on an implementation plan for the required respective governance actions on European scale.
- 242: See Guide Book
- 243: See Guide Book; Ongoing process, also affected by technology
- 244: This milestone will be achieved through several actions. / (See Guide Book)
- 245: This Milestone will be reached through several actions (see Guide Book)
- 248: Regional/National Analysis for the introduction of an integrated timetable

| ID | WBS | Task | Type | Duration | Start | Finish | Predecessors | Total slack | Free slack | Constraint | Action Field |
| --- | --- | --- | --- | --- | --- | --- | --- | --- | --- | --- | --- |
| 253 | 19.13 | **Comprehensive carefree travelling (travel companion)** |  | 5208.46d | 2016-01-01 | 2030-01-01 |  | 7439.91d |  |  | Governance |
| 254 | 19.13.1 | Analysis of the current ticketing (national level) |  | 24mo | 2016-01-01 | 2017-12-31 |  | 8184.37d | 0.44d | start no earlier than 2016-01-01 | Governance |
| 255 | 19.13.2 | Introduction of easy ticketing (national level) |  | 24mo | 2018-01-01 | 2020-01-01 | 254 | 8183.93d | 743.86d | start no earlier than 2018-01-01 | Governance |
| 256 | 19.13.3 | Analysis of the current ticketing (European level) |  | 36mo | 2022-01-01 | 2024-12-31 | 255 | 7440.07d | 0.15d | start no earlier than 2022-01-01 | Governance |
| 257 | 19.13.4 | Introduction of easy ticketing (European level) |  | 60mo | 2025-01-01 | 2030-01-01 | 255, 256 | 7439.91d |  | start no earlier than 2025-01-01 | Governance |
| 258 | 19.13.5 | Investigation of national passenger information systems |  | 18mo | 2016-01-01 | 2017-07-01 |  | 10602.4d | 0d | start no earlier than 2016-01-01 | Governance |
| 259 | 19.13.6 | Plan for the introduction of a European-wide passenger information system |  | 24mo | 2017-07-01 | 2019-07-02 | 258 | 10602.4d | 0d | start no earlier than 2017-07-01 | Governance |
| 260 | 19.13.7 | Implementation of a European Passenger information system (Co-modal) |  | 24mo | 2019-07-02 | 2021-07-02 | 259 | 10602.4d |  | start no earlier than 2017-07-01 | Governance |
| 261 | 19.14 | H24 T7 working cycle (MS) | milestone | 0mo | 2020-01-01 | 2020-01-01 |  | 11159.5d |  | finish no earlier than 2020-01-01 | Governance |
| 262 | 20 | **Legal framework & Policy Measures** |  | 5456.6d | 2015-06-01 | 2030-01-31 |  | 2356.97d |  |  | Governance |
| 263 | 20.1 | Requirement and objectives of legal framework and policy measures |  | 36mo | 2016-01-01 | 2018-12-31 |  | 2139.37d | 0d | start no earlier than 2016-01-01 | Governance |
| 264 | 20.2 | Development of International coordinated R&D programmes |  | 36mo | 2016-04-01 | 2019-04-02 | 263SS+3mo | 10323.4d | 0d |  | Governance |
| 265 | 20.3 | Implementation of respective funding programmes for new technologies |  | 36mo | 2019-04-02 | 2022-04-02 | 264, 263SS+3mo | 10323.4d |  |  | Governance |
| 266 | 20.4 | Plans and specification of funding for rail infrastructure |  | 48mo | 2016-04-01 | 2020-04-01 | 263SS+3mo | 9579.37d | 0d |  | Governance |
| 267 | 20.5 | Implementation and coordination of respective funding programmes for the infrastructure. |  | 48mo | 2020-04-01 | 2024-04-01 | 266, 263SS+3mo | 9579.37d |  |  | Governance |
| 268 | 20.6 | Analysis and evaluation of existing approval procedures |  | 24mo | 2016-04-01 | 2018-04-01 | 263SS+3mo | 2139.37d | 0d |  | Governance |
| 269 | 20.7 | Development of a harmonised European-wide approval regulation |  | 36mo | 2018-04-01 | 2021-04-01 | 268 | 9951.37d | 0d |  | Governance |
| 270 | 20.8 | International agreement by member states and implementation of the regulations by ERA |  | 24mo | 2021-04-01 | 2023-04-02 | 269 | 9951.37d |  |  | Governance |
| 271 | 20.9 | Analysis of market opening and free competition in the member states |  | 24mo | 2015-06-01 | 2017-05-31 |  | 9517.97d | 0d |  | Governance |
| 272 | 20.10 | Concept for truly open market and free competition in the EU |  | 48mo | 2017-05-31 | 2021-06-01 | 271 | 9517.97d | 0d |  | Governance |
| 273 | 20.11 | International agreement by member states, implementation and permanent controlling of the regulations by ERA |  | 36mo | 2021-06-01 | 2024-05-31 | 272 | 9517.97d |  |  | Governance |
| 274 | 20.12 | **R&D programmes** |  | 1860d | 2025-01-01 | 2030-01-01 |  | 7439.91d |  |  | Governance |
| 275 | 20.12.1 | Elaboration of a holistic approach/concept for respective topics |  | 60mo | 2025-01-01 | 2030-01-01 |  | 7439.91d |  | start no earlier than 2025-01-01 | Governance |
| 276 | 20.13 | Free competition, full market opening, EU focus (MS) | milestone | 0mo | 2022-01-01 | 2022-01-01 | 272 | 10415d |  | finish no earlier than 2022-01-01 | Governance |
| 277 | 20.14 | Simplified approval procedures (MS) | milestone | 0mo | 2022-01-01 | 2022-01-01 |  | 10415d |  | finish no earlier than 2022-01-01 | Governance |

Notes:
- 254: Analysis of the current ticketing and identification of weaknesses and passenger demands
- 255: Introduction of easy ticketing (one for all ticket) on national level
- 256: Analysis of the current ticketing on international level and elaboration of optimisation potential
- 257: Introduction of easy ticketing (one for all ticket) on European level
- 258: Investigation of national passenger information systems and identification of weaknesses and passenger demands considering co-modality aspects
- 259: Elaboration of a plan for the introduction of a European-wide passenger information system
- 260: Implementation of a European Passenger information system for Rail, public transport and Car-/Bike Sharing offers
- 261: See Guide Book
- 263: Analysis and identification of the requirement and the objectives of a legal framework and targeted policy measures on European level to support the migration to and implementation of new technologies in the European rail area for freight and passenger services as well as the transition to full market opening of and truly free competition in European rail services.
- 264: Development and agreement of a comprehensive international coordinated R&D programme for the support of the development and successful market uptake of new technologies and specification of coordinated national and European funding programmes.
- 265: Implementation and coordination of respective funding programmes for new technologies
- 266: Development and agreement of a comprehensive international coordinated plans for the upgrading of the rail infrastructure and specification of coordinated national and European funding programmes.
- 267: Implementation and coordination of respective funding programmes for the infrastructure.
- 268: Analysis and evaluation of existing approval procedures on national and international level for the European rail system with the objective of identification of existing disharmonies and barriers in the framework of the various regulations. Deduction of recommendations for a future simplified and harmonised framework for a single EUropean-wide approval regulation.
- 269: Evaluation of the findings, development of a suitable draft for a future simplified and harmonised framework for a single European-wide approval regulation.
- 270: International agreement by member states and implementation of the regulations by ERA
- 271: Analysis and evaluation of the current situation regarding market opening and free competition in the member states
- 272: Evaluation of the findings by member states and EC with the objective to identify existent barriers and deduction of a suitable concept to realise a truly open rail service market in the EU guaranteeing comprehensive free competition.
- 273: International agreement by member states, implementation and permanent controlling of the regulations by ERA
- 274: ·Elaboration of a holistic approach/concept following the required steps from development to successful implementation in parallel to the R&D in national and European wide programmes (e.g. Shift2Rail)
- 276: See Guide Book
- 277: See Guide Book

| ID | WBS | Task | Type | Duration | Start | Finish | Predecessors | Total slack | Free slack | Constraint | Action Field |
| --- | --- | --- | --- | --- | --- | --- | --- | --- | --- | --- | --- |
| 278 | 20.15 | **Funding schemes to support migration** |  | 5239d | 2016-01-01 | 2030-01-31 |  | 7409.37d | 0d |  | Governance |
| 279 | 20.15.1 | Supporting programmes for private sidings |  | 169mo | 2016-01-01 | 2030-01-31 |  | 7409.37d |  | start no earlier than 2016-01-01 | Governance |
| 280 | 20.15.2 | Supporting programmes for terminals and hubs |  | 169mo | 2016-01-01 | 2030-01-31 |  | 7409.37d |  | start no earlier than 2016-01-01 | Governance |
| 281 | 20.15.3 | Supporting programmes for new technologies and innovations |  | 169mo | 2016-01-01 | 2030-01-31 |  | 7409.37d |  | start no earlier than 2016-01-01 | Governance |
| 282 | 21 | **Collaboration offer driven business model** |  | 3938.78d | 2015-06-01 | 2026-01-01 |  | 2450.92d |  |  | Market uptake |
| 283 | 21.1 | Analysis fo common business practices and models (freight) |  | 36mo | 2015-06-01 | 2018-06-01 |  | 11750d |  |  | Market uptake |
| 284 | 21.2 | Analysis and evaluation of the existing framework conditions/regulations |  | 36mo | 2015-06-01 | 2018-06-01 |  | 10634d | 0d |  | Market uptake |
| 285 | 21.3 | Implementation of recommended framework conditions (-> multi channel, OSS…) |  | 36mo | 2018-06-01 | 2021-06-01 | 284 | 10634d |  |  | Market uptake |
| 286 | 21.4 | Development of new offerings, implementation of capacity selling models |  | 36mo | 2015-06-01 | 2018-06-01 |  | 11750d |  |  | Market uptake |
| 287 | 21.5 | Analysis of framework conditions (business models passenger) |  | 36mo | 2015-06-01 | 2018-06-01 |  | 11750d |  |  | Market uptake |
| 288 | 21.6 | Identification, specification and agreement on applicable recommendations (passenger) |  | 48mo | 2015-06-01 | 2019-06-01 |  | 11378d |  |  | Market uptake |
| 289 | 21.7 | OSS - Single point of contact | milestone | 0mo | 2022-01-01 | 2022-01-01 |  | 10415d |  | finish no earlier than 2022-01-01 | Market uptake |
| 290 | 21.8 | Multichannel distribution approach | milestone, manual | 0mo | 2022-01-01 | 2022-01-01 |  |  |  |  | Market uptake |
| 291 | 21.9 | Logistic engineering, new offerings | milestone | 0mo | 2020-01-01 | 2020-01-01 |  | 11159.5d |  | finish no earlier than 2020-01-01 | Market uptake |
| 292 | 21.10 | Travel card integration |  | 96mo | 2018-01-01 | 2026-01-01 |  | 8927.19d |  | finish no earlier than 2026-01-01 | Market uptake |
| 293 | 21.11 | Collaborative logistics/warehouses (MS) | milestone | 0mo | 2022-01-01 | 2022-01-01 |  | 10415d |  | finish no earlier than 2022-01-01 | Market uptake |
| 294 | 22 | **Permanent Education, Personnel training, continuous learning** |  | 12866d | 2015-06-01 | 2050-01-01 |  | 0d |  |  | Market uptake |
| 295 | 22.1 | Analysis of the current situation & recommendations for improvement |  | 36mo | 2015-06-01 | 2018-06-01 |  | 11192d | 0d |  | Market uptake |
| 296 | 22.2 | Analysis of additional requirements |  | 18mo | 2016-05-31 | 2017-11-30 | 295SS+12mo | 11750d | 558d |  | Market uptake |
| 297 | 22.3 | Identification and specification of required future skills |  | 12mo | 2018-06-01 | 2019-06-01 | 295 | 11192d | 0d |  | Market uptake |
| 298 | 22.4 | Deduction and recommendation of suitable guidelines for future education |  | 12mo | 2018-06-01 | 2019-06-01 | 297SS | 11192d | 0d |  | Market uptake |
| 299 | 22.5 | Approval and agreement of the draft by the member states and set in place by the commission. |  | 6mo | 2019-06-01 | 2019-12-01 | 295, 296, 297, 298 | 11192d |  |  | Market uptake |
| 300 | 22.6 | Permanent training, education, learning on EU wide scope for technical/technological & commercial skills |  | 408.01mo | 2016-01-01 | 2050-01-01 |  | 0d |  | start no earlier than 2016-01-01 | Market uptake |
| 301 | 22.7 | Permanent education on communcation skills |  | 408.01mo | 2016-01-01 | 2050-01-01 |  | 0d |  | start no earlier than 2016-01-01 | Market uptake |

Notes:
- 279: European wide harmonised supporting programmes for new building, upgrading and revitalisation of private sidings (including railports and rail facilities for wagon load services in freight villages) between 2015-2030
- 281: Development of progressing supporting programmes, models for start-up funding and financing to foster the implementation of new technologies and innovations until 2020 and set in servicefor the timeframe 2020-2040
- 283: Analysis and evaluation of common business practices and models in other international/globalised freight transport and logistic markets. Deduction of good practices and recommendations for a suitable transfer to the European rail freight market considering the current as well as future framework conditions for offering services on national and European level.
- 284: Analysis and evaluation of the existing framework conditions/regulations on national and European level, considering the findings. Identification of possible barriers and obstacles including responsible actors and/or stakeholders. Deduction and specification of suitable framework conditions in the European rail freight service and infrastructure area to support the implementation of collaborative offer driven business models.
- 285: Implementation of recommended framework conditions supporting the multi-channel distribution approach, OSS - single point of contact and organisation of collaborative logistices/warehouses for freight services.
- 286: Development of new offerings based on advanced logistic engineering and the implementation of new capacity selling business models in the European rail freight market.
- 287: Analysis and evaluation of the framework conditions and the cooperation models for seamless multimodal passenger services on national and international level with focus on comprehensive state of the art information and ticketing services. Deduction and recommendation of pave the way solutions and suitable measures for improvement of the state of the art.
- 288: Identification, specification and agreement on applicable recommendations for the improvement of existing information and ticketing services as well as a desired future multi-modal cooperation aiming at a single national/international travel service area.
- 293: See Guide Book
- 294: Permanent process - without beginning or end
- 295: Analysis and evaluation of the current situation for education, training and continuous learning of staff at the involved stakeholders. Analysis and evaluation of the respective national and/or international regulations and procedures for education, training, continuous learning and licensing. Deduction of important differences between national and/or stakeholder specific regulations. Recommendations of suitable improvements, standards and harmonisation of rules and regulations.
- 296: Analysis and evaluation of additional requirements for education, training and continuous learning regarding the implementation of new technologies, operational schemes, ICT-based management and advanced business models in the European rail area.
- 297: Identification and specification of required future oriented technical/technological, commercial and communication skills related to the field of application or area of operation of the staff. Deduction of respective applicable concepts/framework for the education, training and continuous learning.
- 298: Deduction and recommendation of suitable guidelines for future education, personal training and continuous learning. Development of a draft for an European framework of recommendations for education, training and continous learning in combination with a draft for European-wide standardised and harmonised regulations and procedures for licensing.
- 299: Approval and agreement of the draft by the member states and set in place by the commission.
- 300: Permanent process - without beginning or end
- 301: Permanent process - without beginning or end
